# Plan FEL D

Schedule from MS Project, 2011-01-24 to 2011-06-22, A marks actual dates.
Halliburton

## Calendars

- Standard: Mon-Fri 08:00-12:00, 13:00-17:00; Sat-Sun off.

## Resources

| Resource |
| --- |
| PCGV |
| MYCR |
| GML |

## Schedule

| ID | WBS | Task | Duration | Start | Finish | Predecessors | Complete | Remaining | Total slack | Free slack | Constraint | Resources | Work | Actual work |
| --- | --- | --- | --- | --- | --- | --- | --- | --- | --- | --- | --- | --- | --- | --- |
| 1 | 1 | **PROYECTO FEL - FASE DEFINICIÓN** | 108d? | 2011-01-24 A | 2011-06-22 |  | 37% | 68.14d? | 0d |  |  |  | 968h | 242h |
| 2 | 1.1 | **Ejecución Fase FEL-D** | 108d? | 2011-01-24 A | 2011-06-22 |  | 37% | 68.14d? | 0d |  |  |  | 968h | 242h |
| 3 | 1.1.1 | **Fase de Inicialización** | 5d? | 2011-01-24 A | 2011-01-28 |  | 80% | 1d? | 103d |  |  |  |  |  |
| 4 | 1.1.1.1 | Reunión de Inicio (Kick Off Meeting) | 1d? | 2011-01-24 A | 2011-01-24 A |  | 100% |  |  |  | start no earlier than 2011-01-24 |  |  |  |
| 5 | 1.1.1.2 | Revisión de Plan e Insumos para el FEL - D | 4d | 2011-01-25 A | 2011-01-28 | 4 | 75% | 1d | 103d |  |  |  |  |  |
| 6 | 1.1.2 | **Fase de Mitigación de Incertidumbres y Evaluación del Escenario** | 18d | 2011-01-31 A | 2011-02-23 |  | 50% | 9d | 85d |  |  |  |  |  |
| 7 | 1.1.2.1 | Ejecución de Actividades de Mitigación y Atención a Recomendaciones | 10d | 2011-01-31 A | 2011-02-11 |  | 50% | 5d | 93d |  | start no earlier than 2011-01-31 |  |  |  |
| 8 | 1.1.2.2 | Ajuste y/o Validación de Distribuciones Probabilistas | 15d | 2011-02-03 A | 2011-02-23 |  | 50% | 7.5d | 85d |  | start no earlier than 2011-02-03 |  |  |  |
| 9 | 1.1.3 | **Fase Conceptual del Escenario Seleccionado** | 102d? | 2011-02-01 A | 2011-06-22 |  | 46% | 55.39d? | 0d |  |  |  | 968h | 242h |
| 10 | 1.1.3.1 | **Elaboración de la Inganieria Básica del Escenario Seleccionado** | 60d | 2011-02-24 A | 2011-05-18 |  | 25% | 45d | 25d |  |  |  | 960h | 240h |
| 11 | 1.1.3.1.1 | Subsuelo | 60d | 2011-02-24 A | 2011-05-18 |  | 25% | 45d | 25d |  | start no earlier than 2011-02-24 | PCGV | 480h | 120h |
| 12 | 1.1.3.1.2 | Pozo | 60d | 2011-02-24 A | 2011-05-18 |  | 25% | 45d | 25d |  | start no earlier than 2011-02-24 | MYCR | 480h | 120h |
| 13 | 1.1.3.2 | **Instalaciones** | 78d? | 2011-03-07 A | 2011-06-22 |  | 40% | 46.9d? | 0d |  |  |  | 8h | 2h |
| 14 | 1.1.3.2.1 | Batería | 1d? | 2011-03-07 A | 2011-03-07 |  | 25% | 0.75d? | 35d | 0d | start no earlier than 2011-03-07 | GML | 8h | 2h |
| 15 | 1.1.3.2.2 | Oleogasoducto Oxiacaque | 60d | 2011-03-08 A | 2011-05-30 | 14 | 30% | 42d | 17d |  |  |  |  |  |
| 16 | 1.1.3.2.3 | Sistema de Compresión y Construcción de Batería Terra | 60d | 2011-03-31 A | 2011-06-22 |  | 50% | 30d | 0d |  | start no earlier than 2011-03-31 |  |  |  |
| 17 | 1.1.3.3 | SSPAIS | 60d | 2011-02-24 A | 2011-05-18 |  | 50% | 30d | 25d |  | start no earlier than 2011-02-24 |  |  |  |
| 18 | 1.1.3.4 | Ajuste y Validación del PLAN INTEGRAL DE EXPLOTACIÓN del Escenario Seleccionado | 10d | 2011-05-16 A | 2011-05-27 |  | 75% | 2.5d | 18d |  | start no earlier than 2011-05-16 |  |  |  |
| 19 | 1.1.3.5 | Evaluación Económica del Proyecto | 90d | 2011-02-01 A | 2011-06-06 |  | 75% | 22.5d | 12d |  | start no earlier than 2011-02-01 |  |  |  |
| 20 | 1.1.4 | **Fase de Preparación de Mitigaciones Futuras de la Incertidumbre** | 5d | 2011-05-30 A | 2011-06-03 |  | 75% | 1.25d | 13d |  |  |  |  |  |
| 21 | 1.1.4.1 | Identificación de Variables de Incertidumbres de Mayor Impacto | 2d | 2011-05-30 A | 2011-05-31 |  | 75% | 0.5d | 15.25d | 0d | start no earlier than 2011-05-30 |  |  |  |
| 22 | 1.1.4.2 | Elaboración del Plan de Mitigación | 3d | 2011-06-01 A | 2011-06-03 | 21 | 75% | 0.75d | 13d |  |  |  |  |  |
| 23 | 1.1.5 | **Fase de Revición y Dictamen** | 13d? | 2011-06-06 A | 2011-06-22 |  | 3% | 12.59d? | 0d |  |  |  |  |  |
| 24 | 1.1.5.1 | Evaluación de Llaves técnicas | 1d? | 2011-06-06 A | 2011-06-06 |  | 25% | 0.75d? | 8d | 0d | start no earlier than 2011-06-06 |  |  |  |
| 25 | 1.1.5.2 | Revisión de Pares | 2d | 2011-06-07 | 2011-06-08 | 24 |  |  | 8d |  |  |  |  |  |
| 26 | 1.1.5.3 | Actualización del Plan del FEL Fase D | 2d | 2011-06-09 | 2011-06-10 | 25 |  |  | 8d |  |  |  |  |  |
| 27 | 1.1.5.4 | Dictamen | 3d | 2011-06-20 | 2011-06-22 |  |  |  | 0d |  | start no earlier than 2011-06-20 |  |  |  |
| 28 | 1.1.6 | Fase de Documentación DSD-3 | 108d? | 2011-01-24 | 2011-06-22 |  |  |  | 0d |  | finish no earlier than 2011-06-22 |  |  |  |
